# TP rekonstravimo darbų atlikimo grafikas

Schedule from MS Project, 2020-09-28 to 2024-01-10, costs in €.

## Calendars

- Standard: Mon-Fri 08:00-12:00, 13:00-17:00; Sat-Sun off. Exceptions (off unless hours are given): 2013-01-01 to 2030-01-01 (Naujieji metai, recurring), 2013-02-16 to 2030-02-16 (Valstybės atkurimo diena, recurring), 2013-03-11 to 2030-03-11 (Nepriklausomybes atkurimo diena, recurring), 2013-05-01 to 2030-05-01 (Tarptautine darbininku diena, recurring), 2013-06-24 to 2030-06-24 (Jonines (Rasos), recurring), 2013-07-06 to 2030-07-06 (Valstybes (Lietuvos karaliaus Mindaugo karunavimo) diena, recurring), 2013-08-15 to 2030-08-15 (Zoline, Sv. Mergeles Marijos dangun emimo svente, recurring), 2013-11-01 to 2030-11-01 (Visu sventuju diena, recurring), 2013-12-24 to 2030-12-24 (Sv. Kucios, recurring), 2013-12-25 to 2030-12-25 (Sv. Kaledos, recurring), 2013-12-26 to 2030-12-26 (Sv. Kaledos (antroji diena), recurring), 2019-06-20 to 2024-04-02 07:30-11:30, 12:15-16:30 (Darbo diena (I-IV) 07:30-16:30, recurring), 2019-06-21 to 2030-12-27 07:30-11:30, 12:15-15:15 (Darbo diena (V) 07:30-15:15, recurring), 2021-04-05 (Sv. Velykos (antroji diena)), 2022-04-18 (Sv. Velykos (antroji diena)), 2023-04-10 (Sv. Velykos (antroji diena)).

## Resources

| Resource | Rate |
| --- | --- |
| Rangovas |  |
| Litgrid AB |  |
| Ekspertizės rangovas |  |
| Infostatyba |  |
| PV |  |
| ESO |  |
| _ITTAD ITTC TIG vyresnysis inžinierius | 17.8 |
| _ITTAD ITTC DPG PVS administratorius | 17.8 |
| _ITTAD ITTC VSG DVS administratorius | 17.8 |
| _ITTAD ITTC DPG duomenų tinklo administratorius (KR) | 17.8 |
| _ITTAD ITTC DPG duomenų tinklo administratorius (IP) | 17.8 |
| _Rangovas |  |
| _ITTAD ITTC TIG grupės vadovas |  |
| _VAD FSS apsaugos sistemų specialistas |  |
| _ITTAD ITTC DPG grupės vadovas |  |
| _ITTAD ITTC TIG technologinio tinklo vyresnysis inžinierius |  |
| _ITTAD ITTC VSG grupės vadovas |  |
| _PTD DSAS darbuotojų saugos ir sveikatos vyresnysis inžinierius |  |
| _PTD DSAS aplinkosaugos vyresnysis inžinierius |  |
| _PTD RAAS skyriaus vadovas |  |
| _SVD SPS STRG RAA vadovaujantis inžinierius |  |
| _SVD SPS režimų planavimo grupės vadovas |  |
| _SVD SPS STRG inžinierius |  |
| _SVD SVC TVG ekspertas |  |
| _SVD SPS režimų planavimo grupės vadovaujantis inžinierius |  |
| _SVD SVC TVG analitikas |  |
| _PTD IPC Statybų priežiūros proceso vadovas |  |
| _ISPS kibernetinės saugos specialistas |  |
| _SD STS vadovaujantis inžinierius |  |
| _SVD ROPS RPPAG elektros apskaitų vadovaujantis inžinierius |  |
| _PTD TCHS linijų vyresnysis inžinierius |  |
| _PTD TCHS PPĮG pastočių vyresnysis inžinierius |  |
| _PTD TCHS RAA įrenginių grupės RAA vyresnysis inžinierius |  |
| _KS komunikacijos projektų vadovas |  |

## Schedule

| ID | WBS | Task | Type | Duration | Start | Finish | Predecessors | Baseline start | Baseline finish | Baseline duration | Total slack | Resources | Work | Cost |
| --- | --- | --- | --- | --- | --- | --- | --- | --- | --- | --- | --- | --- | --- | --- |
| 1 | 1 | S3 - Pasirašyta sutartis | milestone | 0d | 2020-09-28 | 2020-09-28 |  |  |  |  | 0d | Rangovas; Litgrid AB |  |  |
| 2 | 2 | Prašymas pateikti reikalingą dokumentaciją/informaciją projektavimo darbams |  | 5d | 2020-09-28 | 2020-10-05 | 1 |  |  |  | 0d | Rangovas | 40h |  |
| 3 | 3 | Pateikta reikalinga dokumentacija/informacija projektavimo darbams |  | 15d | 2020-10-05 | 2020-10-26 | 2 | 2019-12-18 | 2020-01-27 | 25d | 0d | Litgrid AB | 120h |  |
| 4 | 4 | **I ETAPAS. PROJEKTAVIMAS** |  | 309d? | 2020-09-28 | 2021-12-15 |  | 2019-12-18 | 2020-08-18 | 166d | 20d |  | 7415.44h | 43,606.25 |
| 5 | 4.1 | **Projektiniai pasiūlymai** |  | 309d? | 2020-09-28 | 2021-12-15 |  |  |  |  | 20d |  | 7415.44h | 43,606.25 |
| 6 | 4.1.1 | **Tiekėjo darbų atlikimo grafikas** |  | 56d | 2020-10-26 | 2021-01-14 |  |  |  |  | 0d |  | 0.13h |  |
| 7 | 4.1.1.1 | **Darbų atlikimo grafikas** |  | 56d | 2020-10-26 | 2021-01-14 |  |  |  |  | 0d |  | 0.13h |  |
| 8 | 4.1.1.1.1 | Parengti darbų atlikimo grafiką |  | 1d | 2020-10-26 | 2020-10-27 | 3 |  |  |  | 0d |  |  |  |
| 9 | 4.1.1.1.2 | Pateikti 1 peržiūrai darbų atlikimo grafiką |  | 21d | 2020-10-27 | 2020-11-24 | 8 |  |  |  | 0d | _Rangovas [0.1%] | 0.1h |  |
| 10 | 4.1.1.1.3 | Pateikti pastabas po 1 peržiūros |  | 10d | 2020-11-25 | 2020-12-08 | 9 |  |  |  | 0d |  |  |  |
| 11 | 4.1.1.1.4 | Pateikti 2 peržiūrai darbų atlikimo grafiką |  | 7d | 2020-12-09 | 2020-12-17 | 10 |  |  |  | 0d | _Rangovas [0.1%] | 0.03h |  |
| 12 | 4.1.1.1.5 | Pateikti pastabas po 2 peržiūros |  | 5d | 2020-12-17 | 2020-12-28 | 11 |  |  |  | 0d |  |  |  |
| 13 | 4.1.1.1.6 | Pateikti 3 peržiūrai darbų atlikimo grafiką |  | 7d | 2020-12-28 | 2021-01-07 | 12 |  |  |  | 0d |  |  |  |
| 14 | 4.1.1.1.7 | Pateikti pastabas po 3 peržiūros |  | 5d | 2021-01-07 | 2021-01-14 | 13 |  |  |  | 0d |  |  |  |
| 15 | 4.1.1.1.8 | Darbų atlikimo grafikas suderintas | milestone | 0d | 2021-01-14 | 2021-01-14 | 14 |  |  |  | 0d |  |  |  |
| 16 | 4.1.2 | **I ETAPAS. PROJEKTAVIMAS** |  | 186d? | 2020-09-28 | 2021-06-22 |  |  |  |  | 76d |  | 4711.22h | 30,434.19 |
| 17 | 4.1.2.1 | Prašymas pateikti reikalingą dokumentaciją/informaciją techniniems darbams |  | 5d | 2021-01-14 | 2021-01-21 | 15 |  |  |  | 0d | _Rangovas [0.1%] | 0.02h |  |
| 18 | 4.1.2.2 | Pateikta reikalinga dokumentacija/informacija techniniems darbams |  | 10d | 2021-01-21 | 2021-02-04 | 17 |  |  |  | 0d | _ITTAD ITTC TIG grupės vadovas; _VAD FSS apsaugos sistemų specialistas; _ITTAD ITTC DPG duomenų tinklo administratorius (IP); _ITTAD ITTC DPG duomenų tinklo administratorius (KR); _ITTAD ITTC DPG PVS administratorius; _ITTAD ITTC DPG grupės vadovas; _ITTAD ITTC TIG technologinio tinklo vyresnysis inžinierius; _ITTAD ITTC TIG vyresnysis inžinierius; _ITTAD ITTC VSG DVS administratorius; _ITTAD ITTC VSG grupės vadovas; _PTD DSAS darbuotojų saugos ir sveikatos vyresnysis inžinierius; _PTD DSAS aplinkosaugos vyresnysis inžinierius; _PTD RAAS skyriaus vadovas; _SVD SPS STRG RAA vadovaujantis inžinierius; _SVD SPS režimų planavimo grupės vadovas; _SVD SPS STRG inžinierius; _SVD SVC TVG ekspertas; _SVD SPS režimų planavimo grupės vadovaujantis inžinierius; _SVD SVC TVG analitikas; _PTD IPC Statybų priežiūros proceso vadovas; _ISPS kibernetinės saugos specialistas; _SD STS vadovaujantis inžinierius; _SVD ROPS RPPAG elektros apskaitų vadovaujantis inžinierius | 751h | 5,838.4 |
| 19 | 4.1.2.3 | Specialiųjų prisijungimo sąlygų ir specialiųjų reikalavimų ir visų reikalingų suderinimų, leidimų gavimas |  | 1d? | 2020-09-28 | 2020-09-29 |  |  |  |  | 821d |  |  |  |
| 20 | 4.1.2.4 | Sutikimų iš atsakingų institucijų ir asmenų gavimas |  | 1d? | 2020-09-28 | 2020-09-29 |  |  |  |  | 821d |  |  |  |
| 21 | 4.1.2.5 | Konsultacijos rengimo metu |  | 25d | 2020-09-28 | 2020-11-02 | 1 |  |  |  | 797d | _ITTAD ITTC TIG grupės vadovas; _VAD FSS apsaugos sistemų specialistas; _ITTAD ITTC DPG duomenų tinklo administratorius (IP); _ITTAD ITTC DPG duomenų tinklo administratorius (KR); _ITTAD ITTC DPG PVS administratorius; _ITTAD ITTC DPG grupės vadovas; _ITTAD ITTC TIG technologinio tinklo vyresnysis inžinierius; _ITTAD ITTC TIG vyresnysis inžinierius; _ITTAD ITTC VSG DVS administratorius; _ITTAD ITTC VSG grupės vadovas; _PTD DSAS darbuotojų saugos ir sveikatos vyresnysis inžinierius; _PTD DSAS aplinkosaugos vyresnysis inžinierius; _PTD RAAS skyriaus vadovas; _PTD TCHS linijų vyresnysis inžinierius; _PTD TCHS PPĮG pastočių vyresnysis inžinierius; _PTD TCHS RAA įrenginių grupės RAA vyresnysis inžinierius; _SVD SPS STRG RAA vadovaujantis inžinierius; _SVD SPS režimų planavimo grupės vadovas; _SVD SPS STRG inžinierius; _SVD SVC TVG ekspertas; _PTD IPC Statybų priežiūros proceso vadovas; _SVD SPS režimų planavimo grupės vadovaujantis inžinierius; _SVD SVC TVG analitikas; _ISPS kibernetinės saugos specialistas; _SD STS vadovaujantis inžinierius; _SVD ROPS RPPAG elektros apskaitų vadovaujantis inžinierius | 1639h | 11,423.74 |
| 22 | 4.1.2.6 | Pateikti geologinių tyrinėjimų vietas susiderinimui |  | 5d | 2020-09-28 | 2020-10-05 | 1 |  |  |  | 817d | _Rangovas [0.1%] | 0.02h |  |
| 23 | 4.1.2.7 | Atlikti inžineriniai geodeziniai tyrinėjimai ir pateika įregistravimo pažyma |  | 20d | 2021-02-04 | 2021-03-05 | 18 |  |  |  | 0d | _Rangovas [0.1%] | 0.1h |  |
| 24 | 4.1.2.8 | **Projektiniai pasiūlymai** |  | 75d | 2021-03-05 | 2021-06-22 |  |  |  |  | 0d |  | 2321.08h | 13,172.05 |
| 25 | 4.1.2.8.1 | Projektinių pasiūlymų projekto rengimas |  | 30d | 2021-03-05 | 2021-04-20 | 23 |  |  |  | 0d | _Rangovas [0.1%] | 0h |  |
| 26 | 4.1.2.8.2 | Pakoreguoti ir pateikti projektinių pasiūlymų projektą 1 peržiūrai | milestone | 0d | 2021-04-20 | 2021-04-20 | 25 |  |  |  | 0d |  |  |  |
| 27 | 4.1.2.8.3 | Pateikti pastabas po 1 projektinių pasiūlymų projekto peržiūros |  | 10d | 2021-04-20 | 2021-05-04 | 26 |  |  |  | 0d | _VAD FSS apsaugos sistemų specialistas; _ITTAD ITTC DPG duomenų tinklo administratorius (IP); _ITTAD ITTC DPG duomenų tinklo administratorius (KR); _ITTAD ITTC DPG PVS administratorius; _ITTAD ITTC DPG grupės vadovas; _ITTAD ITTC TIG technologinio tinklo vyresnysis inžinierius; _ITTAD ITTC TIG grupės vadovas; _ITTAD ITTC TIG vyresnysis inžinierius; _ITTAD ITTC VSG DVS administratorius; _ITTAD ITTC VSG grupės vadovas; _PTD DSAS darbuotojų saugos ir sveikatos vyresnysis inžinierius; _PTD DSAS aplinkosaugos vyresnysis inžinierius; _PTD RAAS skyriaus vadovas; _PTD TCHS linijų vyresnysis inžinierius; _PTD TCHS PPĮG pastočių vyresnysis inžinierius; _PTD TCHS RAA įrenginių grupės RAA vyresnysis inžinierius; _SVD SPS STRG RAA vadovaujantis inžinierius; _SVD SPS režimų planavimo grupės vadovas; _SVD SPS STRG inžinierius; _SVD SVC TVG ekspertas; _SVD SPS režimų planavimo grupės vadovaujantis inžinierius; _PTD IPC Statybų priežiūros proceso vadovas; _SVD SVC TVG analitikas; _ISPS kibernetinės saugos specialistas; _SD STS vadovaujantis inžinierius; _SVD ROPS RPPAG elektros apskaitų vadovaujantis inžinierius | 1161h | 5,718.73 |
| 28 | 4.1.2.8.4 | Pakoreguoti ir pateikti projektinių pasiūlymų projektą 2 peržiūrai |  | 10d | 2021-05-04 | 2021-05-18 | 27 |  |  |  | 0d | _Rangovas [0.1%] | 0.05h |  |
| 29 | 4.1.2.8.5 | Pateikti pastabas po 2 projektinių pasiūlymų projekto peržiūros |  | 10d | 2021-05-18 | 2021-06-01 | 28 |  |  |  | 0d | _VAD FSS apsaugos sistemų specialistas; _ITTAD ITTC DPG duomenų tinklo administratorius (IP); _ITTAD ITTC DPG duomenų tinklo administratorius (KR); _ITTAD ITTC DPG PVS administratorius; _ITTAD ITTC DPG grupės vadovas; _ITTAD ITTC TIG technologinio tinklo vyresnysis inžinierius; _ITTAD ITTC TIG grupės vadovas; _ITTAD ITTC TIG vyresnysis inžinierius; _ITTAD ITTC VSG DVS administratorius; _ITTAD ITTC VSG grupės vadovas; _PTD DSAS darbuotojų saugos ir sveikatos vyresnysis inžinierius; _PTD DSAS aplinkosaugos vyresnysis inžinierius; _PTD RAAS skyriaus vadovas; _PTD TCHS linijų vyresnysis inžinierius; _PTD TCHS PPĮG pastočių vyresnysis inžinierius; _PTD TCHS RAA įrenginių grupės RAA vyresnysis inžinierius; _SVD SPS STRG RAA vadovaujantis inžinierius; _SVD SPS režimų planavimo grupės vadovas; _SVD SPS STRG inžinierius; _SVD SVC TVG ekspertas; _SVD SPS režimų planavimo grupės vadovaujantis inžinierius; _SVD SVC TVG analitikas; _ISPS kibernetinės saugos specialistas; _PTD IPC Statybų priežiūros proceso vadovas; _SD STS vadovaujantis inžinierius; _SVD ROPS RPPAG elektros apskaitų vadovaujantis inžinierius | 726h | 4,580.91 |
| 30 | 4.1.2.8.6 | Pakoreguoti ir pateikti projektinių pasiūlymų projektą 3 peržiūrai |  | 5d | 2021-06-01 | 2021-06-08 | 29 |  |  |  | 0d | _Rangovas [0.1%] | 0.02h |  |
| 31 | 4.1.2.8.7 | Pateikti pastabas/suderinti po 3 projektinių pasiūlymų projekto |  | 10d | 2021-06-08 | 2021-06-22 | 30 |  |  |  | 0d | _VAD FSS apsaugos sistemų specialistas; _ITTAD ITTC DPG duomenų tinklo administratorius (IP); _ITTAD ITTC DPG duomenų tinklo administratorius (KR); _ITTAD ITTC DPG PVS administratorius; _ITTAD ITTC DPG grupės vadovas; _ITTAD ITTC TIG technologinio tinklo vyresnysis inžinierius; _ITTAD ITTC TIG grupės vadovas; _ITTAD ITTC TIG vyresnysis inžinierius; _ITTAD ITTC VSG DVS administratorius; _ITTAD ITTC VSG grupės vadovas; _PTD DSAS darbuotojų saugos ir sveikatos vyresnysis inžinierius; _PTD DSAS aplinkosaugos vyresnysis inžinierius; _PTD RAAS skyriaus vadovas; _PTD TCHS linijų vyresnysis inžinierius; _PTD TCHS PPĮG pastočių vyresnysis inžinierius; _PTD TCHS RAA įrenginių grupės RAA vyresnysis inžinierius; _SVD SPS STRG RAA vadovaujantis inžinierius; _SVD SPS režimų planavimo grupės vadovas; _SVD SPS STRG inžinierius; _SVD SVC TVG ekspertas; _SVD SPS režimų planavimo grupės vadovaujantis inžinierius; _PTD IPC Statybų priežiūros proceso vadovas; _SVD SVC TVG analitikas; _ISPS kibernetinės saugos specialistas; _SD STS vadovaujantis inžinierius; _SVD ROPS RPPAG elektros apskaitų vadovaujantis inžinierius | 434h | 2,872.42 |
| 32 | 4.1.2.8.8 | Projektiniai pasiūlymai suderinti | milestone | 0d | 2021-06-22 | 2021-06-22 | 31 |  |  |  | 0d |  |  |  |
| 33 | 4.1.2.8.9 | Projektiniai pasiūlymai patvirtinti | milestone | 0d | 2021-06-22 | 2021-06-22 | 32 |  |  |  | 0d |  |  |  |

Notes:
- 4: jeigu perkame iki rakto - paliekame. / Jeigu perkame atskirai - padaryti inactive ar i�trinti
- 21: Pagal poreikį konsultacijos daromos
- 33: kai taikoma

| ID | WBS | Task | Type | Duration | Start | Finish | Predecessors | Baseline start | Baseline finish | Baseline duration | Total slack | Resources | Work | Cost |
| --- | --- | --- | --- | --- | --- | --- | --- | --- | --- | --- | --- | --- | --- | --- |
| 34 | 4.1.3 | **Statybos leidimas** |  | 133d | 2021-06-08 | 2021-12-15 |  |  |  |  | 10d |  | 2704.08h | 13,172.05 |
| 35 | 4.1.3.1 | Komunikacija - Projektinių pasiūlymų viešinimo procedūros |  | 3d | 2021-06-08 | 2021-06-11 | 36SS-10d |  |  |  | 651d | _KS komunikacijos projektų vadovas | 4h |  |
| 36 | 4.1.3.2 | Techninis projektas pateiktas į Infostatybą su visais reikiamais dokumentais |  | 1d | 2021-06-22 | 2021-06-23 | 32, 33 |  |  |  | 0d | _Rangovas [0.1%] | 0h |  |
| 37 | 4.1.3.3 | Patikrinta pateiktos dokumentacijos sudėtis |  | 3d | 2021-06-23 | 2021-06-29 | 36 |  |  |  | 0d | Infostatyba | 24h |  |
| 38 | 4.1.3.4 | Suinteresuotos organizacijos patikrino pateiktą dokumentaciją |  | 20d | 2021-06-29 | 2021-07-28 | 37 |  |  |  | 0d | Infostatyba | 160h |  |
| 39 | 4.1.3.5 | Išduotas statybos leidimas |  | 3d | 2021-07-28 | 2021-08-02 | 38 |  |  |  | 0d | Infostatyba | 24h |  |
| 40 | 4.1.3.6 | S4 - Statybos leidimas gautas | milestone | 0d | 2021-08-02 | 2021-08-02 | 39 |  |  |  | 0d |  |  |  |
| 41 | 4.1.3.7 | Komunikacija (SLD gavimas) |  | 4d | 2021-08-02 | 2021-08-06 | 40SS |  |  |  | 613d | _KS komunikacijos projektų vadovas | 3h |  |
| 42 | 4.1.3.8 | **TDP (techninis darbo projektas) suderintas/patvirtintas (DAR BUS TIKSLINAMAS)** |  | 96d | 2021-08-02 | 2021-12-15 |  |  |  |  | 0d |  | 2489.08h | 13,172.05 |
| 43 | 4.1.3.8.1 | **Techninis darbo projektas** |  | 96d | 2021-08-02 | 2021-12-15 |  |  |  |  | 0d |  | 2489.08h | 13,172.05 |
| 44 | 4.1.3.8.1.1 | Techninio darbo projekto rengimas |  | 30d | 2021-08-02 | 2021-09-13 | 40 |  |  |  | 0d | _Rangovas [0.1%] | 0h |  |
| 45 | 4.1.3.8.1.2 | Pakoreguoti ir pateikti techninį darbo projektą 1 peržiūrai | milestone | 0d | 2021-09-13 | 2021-09-13 | 44 |  |  |  | 0d |  |  |  |
| 46 | 4.1.3.8.1.3 | Pateikti pastabas po 1 techninio darbo projekto peržiūros |  | 10d | 2021-09-13 | 2021-09-27 | 45 |  |  |  | 0d | _VAD FSS apsaugos sistemų specialistas; _ITTAD ITTC DPG duomenų tinklo administratorius (IP); _ITTAD ITTC DPG duomenų tinklo administratorius (KR); _ITTAD ITTC DPG PVS administratorius; _ITTAD ITTC DPG grupės vadovas; _ITTAD ITTC TIG technologinio tinklo vyresnysis inžinierius; _ITTAD ITTC TIG grupės vadovas; _ITTAD ITTC TIG vyresnysis inžinierius; _ITTAD ITTC VSG DVS administratorius; _ITTAD ITTC VSG grupės vadovas; _PTD DSAS darbuotojų saugos ir sveikatos vyresnysis inžinierius; _PTD DSAS aplinkosaugos vyresnysis inžinierius; _PTD RAAS skyriaus vadovas; _PTD TCHS linijų vyresnysis inžinierius; _PTD TCHS PPĮG pastočių vyresnysis inžinierius; _PTD TCHS RAA įrenginių grupės RAA vyresnysis inžinierius; _SVD SPS STRG RAA vadovaujantis inžinierius; _SVD SPS režimų planavimo grupės vadovas; _SVD SPS STRG inžinierius; _SVD SVC TVG ekspertas; _SVD SPS režimų planavimo grupės vadovaujantis inžinierius; _PTD IPC Statybų priežiūros proceso vadovas; _SVD SVC TVG analitikas; _ISPS kibernetinės saugos specialistas; _SD STS vadovaujantis inžinierius; _SVD ROPS RPPAG elektros apskaitų vadovaujantis inžinierius | 1161h | 5,718.73 |
| 47 | 4.1.3.8.1.4 | Pakoreguoti ir pateikti techninį darbo projektą 2 peržiūrai |  | 10d | 2021-09-27 | 2021-10-11 | 46 |  |  |  | 0d | _Rangovas [0.1%] | 0.05h |  |
| 48 | 4.1.3.8.1.5 | Pateikti pastabas po 2 techninio darbo projekto peržiūros |  | 10d | 2021-10-11 | 2021-10-25 | 47 |  |  |  | 0d | _VAD FSS apsaugos sistemų specialistas; _ITTAD ITTC DPG duomenų tinklo administratorius (IP); _ITTAD ITTC DPG duomenų tinklo administratorius (KR); _ITTAD ITTC DPG PVS administratorius; _ITTAD ITTC DPG grupės vadovas; _ITTAD ITTC TIG technologinio tinklo vyresnysis inžinierius; _ITTAD ITTC TIG grupės vadovas; _ITTAD ITTC TIG vyresnysis inžinierius; _ITTAD ITTC VSG DVS administratorius; _ITTAD ITTC VSG grupės vadovas; _PTD DSAS darbuotojų saugos ir sveikatos vyresnysis inžinierius; _PTD DSAS aplinkosaugos vyresnysis inžinierius; _PTD RAAS skyriaus vadovas; _PTD TCHS linijų vyresnysis inžinierius; _PTD TCHS PPĮG pastočių vyresnysis inžinierius; _PTD TCHS RAA įrenginių grupės RAA vyresnysis inžinierius; _SVD SPS STRG RAA vadovaujantis inžinierius; _SVD SPS režimų planavimo grupės vadovas; _SVD SPS STRG inžinierius; _SVD SVC TVG ekspertas; _SVD SPS režimų planavimo grupės vadovaujantis inžinierius; _SVD SVC TVG analitikas; _ISPS kibernetinės saugos specialistas; _PTD IPC Statybų priežiūros proceso vadovas; _SD STS vadovaujantis inžinierius; _SVD ROPS RPPAG elektros apskaitų vadovaujantis inžinierius | 726h | 4,580.91 |
| 49 | 4.1.3.8.1.6 | Pakoreguoti ir pateikti techninį darbo projektą 3 peržiūrai |  | 5d | 2021-10-25 | 2021-11-02 | 48 |  |  |  | 0d | _Rangovas [0.1%] | 0.02h |  |
| 50 | 4.1.3.8.1.7 | Pateikti pastabas/suderinti po 3 techninio darbo projekto peržiūros |  | 10d | 2021-11-02 | 2021-11-16 | 49 |  |  |  | 0d | _VAD FSS apsaugos sistemų specialistas; _ITTAD ITTC DPG duomenų tinklo administratorius (IP); _ITTAD ITTC DPG duomenų tinklo administratorius (KR); _ITTAD ITTC DPG PVS administratorius; _ITTAD ITTC DPG grupės vadovas; _ITTAD ITTC TIG technologinio tinklo vyresnysis inžinierius; _ITTAD ITTC TIG grupės vadovas; _ITTAD ITTC TIG vyresnysis inžinierius; _ITTAD ITTC VSG DVS administratorius; _ITTAD ITTC VSG grupės vadovas; _PTD DSAS darbuotojų saugos ir sveikatos vyresnysis inžinierius; _PTD DSAS aplinkosaugos vyresnysis inžinierius; _PTD RAAS skyriaus vadovas; _PTD TCHS linijų vyresnysis inžinierius; _PTD TCHS PPĮG pastočių vyresnysis inžinierius; _PTD TCHS RAA įrenginių grupės RAA vyresnysis inžinierius; _SVD SPS STRG RAA vadovaujantis inžinierius; _SVD SPS režimų planavimo grupės vadovas; _SVD SPS STRG inžinierius; _SVD SVC TVG ekspertas; _SVD SPS režimų planavimo grupės vadovaujantis inžinierius; _PTD IPC Statybų priežiūros proceso vadovas; _SVD SVC TVG analitikas; _ISPS kibernetinės saugos specialistas; _SD STS vadovaujantis inžinierius; _SVD ROPS RPPAG elektros apskaitų vadovaujantis inžinierius | 434h | 2,872.42 |
| 51 | 4.1.3.8.1.8 | Techninis darbo projektas suderintas | milestone | 0d | 2021-11-16 | 2021-11-16 | 50 |  |  |  | 0d |  |  |  |
| 52 | 4.1.3.8.1.9 | **Techninio darbo projekto bendroji ekspertizė** |  | 21d | 2021-11-16 | 2021-12-15 |  |  |  |  | 0d |  | 168h |  |
| 53 | 4.1.3.8.1.9.1 | Techninio darbo projekto bendroji ekspertizė |  | 20d | 2021-11-16 | 2021-12-14 | 51 |  |  |  | 0d | Ekspertizės rangovas | 160h |  |
| 54 | 4.1.3.8.1.9.2 | Pateikta ekspertizės teigiama išvada projektui |  | 1d | 2021-12-14 | 2021-12-15 | 53 |  |  |  | 0d | Ekspertizės rangovas | 8h |  |
| 55 | 4.1.3.8.1.9.3 | S5 - Gautas teigiamas techninio darbo projekto - TDP ekspertizės aktas | milestone | 0d | 2021-12-15 | 2021-12-15 | 56 |  |  |  | 0d |  |  |  |
| 56 | 4.1.3.8.1.9.4 | Patvirtintas statinio projektas statytojo tvarkomuoju dokumentu, nurodant pagrindinius statinio techninius ir ekonominius duomenis, aplinkos ir kraštovaizdžio reikalavimus | milestone | 0d | 2021-12-15 | 2021-12-15 | 54 |  |  |  | 0d |  |  |  |
| 57 | 5 | **II ETAPAS. RANGOS DARBAI** |  | 779d? | 2020-09-28 | 2023-10-24 |  | 2020-05-19 | 2022-01-18 | 424d | 51d |  | 15600h | 5,411.2 |
| 58 | 5.1 | Darbams atlikti reikalingos dokumentacijos pateikimas Rangovui |  | 1d? | 2020-09-28 | 2020-09-29 |  |  |  |  | 821d |  |  |  |
| 59 | 5.2 | Pranešimas apie statybos pradžią Užsakovo vardu |  | 1d? | 2020-09-28 | 2020-09-29 |  |  |  |  | 821d |  |  |  |

Notes:
- 35: Jei reikalingas projektinių sprendinių pristatymas visuomenei (vie�inimo procedūros) pagal teisės aktus. Tikslas - vie�inti Litgrid tinklapyje apie projektinių sprendinių vie�inimo procedūr¹.
- 57: jei perkame atskirai (tik projektavim¹) - trinti �i¹ dalį/ jei perkame iki rakto - paliekame
- 58: vykdo u˛sakovas

| ID | WBS | Task | Duration | Start | Finish | Predecessors | Baseline start | Baseline finish | Baseline duration | Total slack | Free slack | Resources | Work |
| --- | --- | --- | --- | --- | --- | --- | --- | --- | --- | --- | --- | --- | --- |
| 60 | 5.3 | **Pagrindinės įrangos parinkimas ir suderinimas** | 364d? | 2020-09-28 | 2022-03-04 |  | 2020-05-19 | 2020-06-19 | 24d | 309d |  |  | 3520h |
| 61 | 5.3.1 | **Elektrotechnika [E]** | 55d | 2021-12-15 | 2022-03-04 |  | 2020-05-19 | 2020-06-19 | 24d | 0d |  |  | 440h |
| 62 | 5.3.1.1 | Parinkta elektrotechnikos dalies įranga ir pateikti 1 peržiūrai užpildyti techninių specifikacijų atitikimai LITGRID AB | 30d | 2021-12-15 | 2022-01-27 | 55 | 2020-05-19 | 2020-06-01 | 10d | 0d |  | Rangovas | 240h |
| 63 | 5.3.1.2 | Pateiktos pastabos užpildytoms techninėms specifikacijoms | 10d | 2022-01-27 | 2022-02-10 | 62 | 2020-06-02 | 2020-06-15 | 10d | 0d |  | Litgrid AB | 80h |
| 64 | 5.3.1.3 | Patikslinti techninių specifikacijų atitikimai ir pateikti 2 peržiūrai Litgrid AB | 5d | 2022-02-10 | 2022-02-18 | 63 | 2020-06-16 | 2020-06-17 | 2d | 0d |  | Rangovas | 40h |
| 65 | 5.3.1.4 | Patvirtinti techninių specifikacijų atitikimai - įranga suderinta | 10d | 2022-02-18 | 2022-03-04 | 64 | 2020-06-18 | 2020-06-19 | 2d | 0d |  | Litgrid AB | 80h |
| 66 | 5.3.2 | **Elektrotechnika (EL)** | 55d | 2021-12-15 | 2022-03-04 |  | 2020-05-19 | 2020-06-12 | 19d | 431d |  |  | 440h |
| 67 | 5.3.2.1 | Parinktos EL dalies medžiagos ir pateikti 1 peržiūrai užpildyti techninių specifikacijų atitikimai LITGRID AB | 30d | 2021-12-15 | 2022-01-27 | 55 | 2020-05-19 | 2020-05-25 | 5d | 431d | 0d | Rangovas | 240h |
| 68 | 5.3.2.2 | Pateiktos pastabos užpildytoms techninėms specifikacijoms | 10d | 2022-01-27 | 2022-02-10 | 67 | 2020-05-26 | 2020-06-08 | 10d | 431d | 0d | Litgrid AB | 80h |
| 69 | 5.3.2.3 | Patikslinti techninių specifikacijų atitikimai ir pateikti 2 peržiūrai Litgrid AB | 5d | 2022-02-10 | 2022-02-18 | 68 | 2020-06-09 | 2020-06-10 | 2d | 431d | 0d | Rangovas | 40h |
| 70 | 5.3.2.4 | Patvirtinti techninių specifikacijų atitikimai - įranga suderinta | 10d | 2022-02-18 | 2022-03-04 | 69 | 2020-06-11 | 2020-06-12 | 2d | 431d | 0d | Litgrid AB | 80h |
| 71 | 5.3.3 | **Procesų valdymas ir automatizacija (RAA)** | 55d | 2021-12-15 | 2022-03-04 |  | 2020-05-19 | 2020-06-19 | 24d | 47d |  |  | 440h |
| 72 | 5.3.3.1 | Parinkta RAA dalies įranga ir pateikti 1 peržiūrai užpildyti techninių specifikacijų atitikimai LITGRID AB | 30d | 2021-12-15 | 2022-01-27 | 55 | 2020-05-19 | 2020-06-01 | 10d | 47d | 0d | Rangovas | 240h |
| 73 | 5.3.3.2 | Pateiktos pastabos užpildytoms techninėms specifikacijoms | 10d | 2022-01-27 | 2022-02-10 | 72 | 2020-06-02 | 2020-06-15 | 10d | 47d | 0d | Litgrid AB | 80h |
| 74 | 5.3.3.3 | Patikslinti techninių specifikacijų atitikimai ir pateikti 2 peržiūrai Litgrid AB | 5d | 2022-02-10 | 2022-02-18 | 73 | 2020-06-16 | 2020-06-17 | 2d | 47d | 0d | Rangovas | 40h |
| 75 | 5.3.3.4 | Patvirtinti techninių specifikacijų atitikimai - įranga suderinta | 10d | 2022-02-18 | 2022-03-04 | 74 | 2020-06-18 | 2020-06-19 | 2d | 47d | 0d | Litgrid AB | 80h |
| 76 | 5.3.4 | **Procesų valdymas ir automatizacija (TSPĮ)** | 55d | 2020-09-28 | 2020-12-14 |  | 2020-05-19 | 2020-06-12 | 19d | 740d |  |  | 440h |
| 77 | 5.3.4.1 | Parinkta TSPĮ dalies įranga ir pateikti 1 peržiūrai užpildyti techninių specifikacijų atitikimai LITGRID AB | 30d | 2020-09-28 | 2020-11-09 |  | 2020-05-19 | 2020-05-25 | 5d | 732d | 0d | Rangovas | 240h |
| 78 | 5.3.4.2 | Pateiktos pastabos užpildytoms techninėms specifikacijoms | 10d | 2020-11-09 | 2020-11-23 | 77 | 2020-05-26 | 2020-06-08 | 10d | 732d | 0d | Litgrid AB | 80h |
| 79 | 5.3.4.3 | Patikslinti techninių specifikacijų atitikimai ir pateikti 2 peržiūrai Litgrid AB | 5d | 2020-11-23 | 2020-11-30 | 78 | 2020-06-09 | 2020-06-10 | 2d | 732d | 0d | Rangovas | 40h |
| 80 | 5.3.4.4 | Patvirtinti techninių specifikacijų atitikimai - įranga suderinta | 10d | 2020-11-30 | 2020-12-14 | 79 | 2020-06-11 | 2020-06-12 | 2d | 732d | 0d | Litgrid AB | 80h |
| 81 | 5.3.5 | **Procesų valdymas ir automatizacija (EEA)** | 55d | 2021-12-15 | 2022-03-04 |  | 2020-05-19 | 2020-06-12 | 19d | 431d |  |  | 440h |
| 82 | 5.3.5.1 | Parinkta EEA dalies įranga ir pateikti 1 peržiūrai užpildyti techninių specifikacijų atitikimai LITGRID AB | 30d | 2021-12-15 | 2022-01-27 | 55 | 2020-05-19 | 2020-05-25 | 5d | 431d | 0d | Rangovas | 240h |
| 83 | 5.3.5.2 | Pateiktos pastabos užpildytoms techninėms specifikacijoms | 10d | 2022-01-27 | 2022-02-10 | 82 | 2020-05-26 | 2020-06-08 | 10d | 431d | 0d | Litgrid AB | 80h |
| 84 | 5.3.5.3 | Patikslinti techninių specifikacijų atitikimai ir pateikti 2 peržiūrai Litgrid AB | 5d | 2022-02-10 | 2022-02-18 | 83 | 2020-06-09 | 2020-06-10 | 2d | 431d | 0d | Rangovas | 40h |
| 85 | 5.3.5.4 | Patvirtinti techninių specifikacijų atitikimai - įranga suderinta | 10d | 2022-02-18 | 2022-03-04 | 84 | 2020-06-11 | 2020-06-12 | 2d | 431d | 0d | Litgrid AB | 80h |

| ID | WBS | Task | Duration | Start | Finish | Predecessors | Baseline start | Baseline finish | Baseline duration | Total slack | Free slack | Resources | Work |
| --- | --- | --- | --- | --- | --- | --- | --- | --- | --- | --- | --- | --- | --- |
| 86 | 5.3.6 | **Telekomunikacijos (TK)** | 55d | 2021-12-15 | 2022-03-04 |  | 2020-05-19 | 2020-06-12 | 19d | 426d |  |  | 440h |
| 87 | 5.3.6.1 | Parinkta telekomunikacijos dalies įranga ir pateikti 1 peržiūrai užpildyti techninių specifikacijų atitikimai LITGRID AB | 30d | 2021-12-15 | 2022-01-27 | 55 | 2020-05-19 | 2020-05-25 | 5d | 426d | 0d | Rangovas | 240h |
| 88 | 5.3.6.2 | Pateiktos pastabos užpildytoms techninėms specifikacijoms | 10d | 2022-01-27 | 2022-02-10 | 87 | 2020-05-26 | 2020-06-08 | 10d | 426d | 0d | Litgrid AB | 80h |
| 89 | 5.3.6.3 | Patikslinti techninių specifikacijų atitikimai ir pateikti pakartotinei peržiūrai Litgrid AB | 5d | 2022-02-10 | 2022-02-18 | 88 | 2020-06-09 | 2020-06-10 | 2d | 426d | 0d | Rangovas | 40h |
| 90 | 5.3.6.4 | Patvirtinti techninių specifikacijų atitikimai - įranga suderinta | 10d | 2022-02-18 | 2022-03-04 | 89 | 2020-06-11 | 2020-06-12 | 2d | 426d | 0d | Litgrid AB | 80h |
| 91 | 5.3.7 | **Apsauginė-gaisrinė signalizacija (AGS)** | 55d | 2021-12-15 | 2022-03-04 |  | 2020-05-19 | 2020-06-12 | 19d | 431d |  |  | 440h |
| 92 | 5.3.7.1 | Parinkta AGS dalies įranga ir pateikti peržiūrai užpildyti techninių specifikacijų atitikimai LITGRID AB | 30d | 2021-12-15 | 2022-01-27 | 55 | 2020-05-19 | 2020-05-25 | 5d | 431d | 0d | Rangovas | 240h |
| 93 | 5.3.7.2 | Pateiktos pastabos užpildytoms techninėms specifikacijoms | 10d | 2022-01-27 | 2022-02-10 | 92 | 2020-05-26 | 2020-06-08 | 10d | 431d | 0d | Litgrid AB | 80h |
| 94 | 5.3.7.3 | Patikslinti techninių specifikacijų atitikimai ir pateikti pakartotinei peržiūrai Litgrid AB | 5d | 2022-02-10 | 2022-02-18 | 93 | 2020-06-09 | 2020-06-10 | 2d | 431d | 0d | Rangovas | 40h |
| 95 | 5.3.7.4 | Patvirtinti techninių specifikacijų atitikimai - įranga suderinta | 10d | 2022-02-18 | 2022-03-04 | 94 | 2020-06-11 | 2020-06-12 | 2d | 431d | 0d | Litgrid AB | 80h |
| 96 | 5.3.8 | **Statybinės konstrukcijos (SK)** | 364d? | 2020-09-28 | 2022-03-04 |  | 2020-05-19 | 2020-06-12 | 19d | 314d |  |  | 440h |
| 97 | 5.3.8.1 | Parinktos SK dalies medžiagos ir pateikti peržiūrai užpildyti techninių specifikacijų atitikimai LITGRID AB | 30d | 2021-12-15 | 2022-01-27 | 55 | 2020-05-19 | 2020-05-25 | 5d | 5d | 0d | Rangovas | 240h |
| 98 | 5.3.8.2 | Pateiktos pastabos užpildytoms techninėms specifikacijoms | 10d | 2022-01-27 | 2022-02-10 | 97 | 2020-05-26 | 2020-06-08 | 10d | 5d | 0d | Litgrid AB | 80h |
| 99 | 5.3.8.3 | Patikslinti techninių specifikacijų atitikimai ir pateikti pakartotinei peržiūrai Litgrid AB | 5d | 2022-02-10 | 2022-02-18 | 98 | 2020-06-09 | 2020-06-10 | 2d | 5d | 0d | Rangovas | 40h |
| 100 | 5.3.8.4 | Patvirtinti techninių specifikacijų atitikimai - įranga suderinta | 10d | 2022-02-18 | 2022-03-04 | 99 | 2020-06-11 | 2020-06-12 | 2d | 5d | 0d | Litgrid AB | 80h |
| 101 | 5.3.8.5 | Pateikti įrodantys dokumentai, kad Pagrindiniai įrenginiai yra užsakyti | 1d? | 2020-09-28 | 2020-09-29 |  |  |  |  | 821d |  |  |  |
| 102 | 5.4 | **RAA nuostatų pateikimas I statybos etapui** | 68d | 2022-03-04 | 2022-06-10 |  | 2020-06-22 | 2020-09-21 | 64d | 47d |  |  | 544h |
| 103 | 5.4.1 | OL RAA nuostatų I rekonstrukcijos etapui skaičiavimas | 21d | 2022-03-04 | 2022-04-05 | 75 |  |  |  | 47d | 0d | Litgrid AB | 168h |
| 104 | 5.4.2 | OL RAA nuostatų I rekonstrukcijos etapo užduočių rengimas | 13d | 2022-04-05 | 2022-04-25 | 103 |  |  |  | 47d | 0d | Litgrid AB | 104h |
| 105 | 5.4.3 | Šynų; prijunginių jungtuvų RAA nuostatų I rekonstrukcijos etapui skaičiavimas ir užduočių rengimas | 13d | 2022-04-25 | 2022-05-12 | 104 |  |  |  | 47d | 0d | Litgrid AB | 104h |
| 106 | 5.4.4 | Galios transformatorių įvadų TS- 100 RAA nuostatų skaičiavimas 15 dienų | 15d | 2022-05-12 | 2022-06-02 | 105 |  |  |  | 47d | 0d | Litgrid AB | 120h |
| 107 | 5.4.5 | I rekonstrukcijos etapo užduočių rengimas | 5d | 2022-06-02 | 2022-06-09 | 106 |  |  |  | 47d | 0d | Litgrid AB | 40h |
| 108 | 5.4.6 | Užduočių pateikimas | 1d | 2022-06-09 | 2022-06-10 | 107 |  |  |  | 47d | 0d | Litgrid AB | 8h |
| 109 | 5.5 | **I darbų etapo signalų sąrašai** | 50d | 2022-06-10 | 2022-08-24 |  |  |  |  | 47d |  |  | 640h |
| 110 | 5.5.1 | Suprojektuoti ir pateikti 1 peržiūrai ir derinimui XX TP; bei kitų su XX TP rekonstrukcija susijusių objektų (pagal poreikį); signalų sąrašai Litgrid AB ir ESO | 10d | 2022-06-10 | 2022-06-27 | 108 | 2020-10-21 | 2020-11-10 | 15d | 47d | 0d | Rangovas | 80h |
| 111 | 5.5.2 | Pateiktos pastabos po 1 peržiūros | 15d | 2022-06-27 | 2022-07-19 | 110 | 2020-11-11 | 2020-12-01 | 15d | 47d | 0d | Litgrid AB; ESO | 240h |
| 112 | 5.5.3 | Pakoreguoti pagal pastabas ir pateikti 2 peržiūrai ir derinimui signalų sąrašai Litgrid AB ir ESO | 5d | 2022-07-19 | 2022-07-26 | 111 | 2020-12-02 | 2020-12-08 | 5d | 47d | 0d | Rangovas | 40h |
| 113 | 5.5.4 | Pateiktos pastabos po 2 peržiūros | 10d | 2022-07-26 | 2022-08-09 | 112 | 2020-12-09 | 2020-12-22 | 10d | 47d | 0d | Litgrid AB; ESO | 160h |
| 114 | 5.5.5 | Pakoreguoti pagal pastabas ir pateikti III peržiūrai ir derinimui signalų sąrašai Litgrid AB ir ESO | 5d | 2022-08-09 | 2022-08-17 | 113 | 2020-12-23 | 2020-12-31 | 5d | 47d | 0d | Rangovas | 40h |
| 115 | 5.5.6 | I darbų etapo signalų sąrašai suderinti | 5d | 2022-08-17 | 2022-08-24 | 114 | 2021-01-04 | 2021-01-08 | 5d | 47d | 0d | Litgrid AB; ESO | 80h |

Notes:
- 101: Pagrindiniai įrenginiai - įrenginiai, kurie Sutartyje ir/ar kituose Pirkimo dokumentuose nurodyti kaip pagrindiniai.

| ID | WBS | Task | Type | Duration | Start | Finish | Predecessors | Baseline start | Baseline finish | Baseline duration | Total slack | Free slack | Resources | Work |
| --- | --- | --- | --- | --- | --- | --- | --- | --- | --- | --- | --- | --- | --- | --- |
| 116 | 5.6 | **Darbo projektas (NESUSITARTA dar yra dėl šios dalies)** |  | 394d | 2020-12-14 | 2022-07-07 |  | 2020-08-19 | 2021-01-28 | 114d | 309d |  |  | 3040h |
| 117 | 5.6.1 | **Sklypo planas (SP)** |  | 35d | 2022-05-03 | 2022-06-21 |  | 2020-11-12 | 2021-01-04 | 35d | 0d |  |  | 280h |
| 118 | 5.6.1.1 | Suprojektuota ir pateikta 1 peržiūrai |  | 10d | 2022-05-03 | 2022-05-17 | 127, 133 | 2020-11-12 | 2020-11-25 | 10d | 0d |  | Rangovas | 80h |
| 119 | 5.6.1.2 | Pateiktos pastabos po 1 peržiūros |  | 15d | 2022-05-17 | 2022-06-07 | 118 | 2020-11-26 | 2020-12-16 | 15d | 0d |  | Litgrid AB | 120h |
| 120 | 5.6.1.3 | Pakoreguota pagal pastabas ir pateikta 2 peržiūrai |  | 5d | 2022-06-07 | 2022-06-14 | 119 | 2020-12-17 | 2020-12-23 | 5d | 0d |  | Rangovas | 40h |
| 121 | 5.6.1.4 | Darbo projekto dalis suderinta |  | 5d | 2022-06-14 | 2022-06-21 | 120 | 2020-12-28 | 2021-01-04 | 5d | 0d |  | Litgrid AB | 40h |
| 122 | 5.6.1.5 | Darbo projekto pateikimas Statytojui su žyma "Pritariu statyti" | inactive | 5d | 2022-06-21 | 2022-06-29 | 121 |  |  |  | 386d |  | Rangovas | 40h |
| 123 | 5.6.2 | **Elektrotechnika [E]** |  | 40d | 2022-03-04 | 2022-05-03 |  | 2020-08-19 | 2020-10-13 | 40d | 0d |  |  | 320h |
| 124 | 5.6.2.1 | Suprojektuota ir pateikta 1 peržiūrai |  | 15d | 2022-03-04 | 2022-03-28 | 65 | 2020-08-19 | 2020-09-08 | 15d | 0d |  | Rangovas | 120h |
| 125 | 5.6.2.2 | Pateiktos pastabos po 1 peržiūros |  | 15d | 2022-03-28 | 2022-04-19 | 124 | 2020-09-09 | 2020-09-29 | 15d | 0d |  | Litgrid AB | 120h |
| 126 | 5.6.2.3 | Pakoreguota pagal pastabas ir pateikta 2 peržiūrai |  | 5d | 2022-04-19 | 2022-04-26 | 125 | 2020-09-30 | 2020-10-06 | 5d | 0d |  | Rangovas | 40h |
| 127 | 5.6.2.4 | Darbo projekto dalis suderinta |  | 5d | 2022-04-26 | 2022-05-03 | 126 | 2020-10-07 | 2020-10-13 | 5d | 0d |  | Litgrid AB | 40h |
| 128 | 5.6.2.5 | Darbo projekto pateikimas Statytojui su žyma "Pritariu statyti" | inactive | 5d | 2022-05-03 | 2022-05-10 | 127 |  |  |  | 421d |  | Rangovas | 40h |
| 129 | 5.6.3 | **Konstrukcijos (SK)** |  | 35d | 2022-03-04 | 2022-04-26 |  | 2020-08-19 | 2020-11-11 | 61d | 5d |  |  | 280h |
| 130 | 5.6.3.1 | Suprojektuota ir pateikta 1 peržiūrai |  | 10d | 2022-03-04 | 2022-03-21 | 100 | 2020-08-19 | 2020-09-01 | 10d | 5d | 0d | Rangovas | 80h |
| 131 | 5.6.3.2 | Pateiktos pastabos po 1 peržiūros |  | 15d | 2022-03-21 | 2022-04-11 | 130 | 2020-09-02 | 2020-09-22 | 15d | 5d | 0d | Litgrid AB | 120h |
| 132 | 5.6.3.3 | Pakoreguota pagal pastabas ir pateikta 2 peržiūrai |  | 5d | 2022-04-11 | 2022-04-19 | 131 | 2020-09-23 | 2020-09-29 | 5d | 5d | 0d | Rangovas | 40h |
| 133 | 5.6.3.4 | Darbo projekto dalis suderinta |  | 5d | 2022-04-19 | 2022-04-26 | 132 | 2020-09-30 | 2020-10-06 | 5d | 5d | 0d | Litgrid AB | 40h |
| 134 | 5.6.3.5 | Pateikta SK darbo projekto dalis ekspertizei | inactive | 1d | 2022-04-26 | 2022-04-27 | 133 | 2020-10-07 | 2020-10-07 | 1d | 14d | 0d | Litgrid AB | 8h |
| 135 | 5.6.3.6 | Pateiktos ekspertizės pastabos | inactive | 15d | 2022-04-27 | 2022-05-18 | 134 | 2020-10-08 | 2020-10-28 | 15d | 14d | 0d | Ekspertizės rangovas; Litgrid AB | 240h |
| 136 | 5.6.3.7 | Pateikta pakoreguota SK darbo projekto dalis ekspertizei | inactive | 5d | 2022-05-18 | 2022-05-25 | 135 | 2020-10-29 | 2020-11-04 | 5d | 14d | 0d | Rangovas | 40h |
| 137 | 5.6.3.8 | Gautos teigiamos ekspertizės išvados | inactive | 5d | 2022-05-25 | 2022-06-01 | 136 | 2020-11-05 | 2020-11-11 | 5d | 14d | 0d | Ekspertizės rangovas | 40h |
| 138 | 5.6.3.9 | Darbo projekto pateikimas Statytojui su žyma "Pritariu statyti" | inactive | 5d | 2022-06-01 | 2022-06-08 | 137 |  |  |  | 400d |  | Rangovas | 40h |
| 139 | 5.6.4 | **Elektrotechnika (EL)** |  | 35d | 2022-03-04 | 2022-04-26 |  | 2020-08-19 | 2020-10-06 | 35d | 431d |  |  | 280h |
| 140 | 5.6.4.1 | Suprojektuota ir pateikta 1 peržiūrai |  | 10d | 2022-03-04 | 2022-03-21 | 70 | 2020-08-19 | 2020-09-01 | 10d | 431d | 0d | Rangovas | 80h |
| 141 | 5.6.4.2 | Pateiktos pastabos po 1 peržiūros |  | 15d | 2022-03-21 | 2022-04-11 | 140 | 2020-09-02 | 2020-09-22 | 15d | 431d | 0d | Litgrid AB | 120h |
| 142 | 5.6.4.3 | Pakoreguota pagal pastabas ir pateikta 2 peržiūrai |  | 5d | 2022-04-11 | 2022-04-19 | 141 | 2020-09-23 | 2020-09-29 | 5d | 431d | 0d | Rangovas | 40h |
| 143 | 5.6.4.4 | Darbo projekto dalis suderinta |  | 5d | 2022-04-19 | 2022-04-26 | 142 | 2020-09-30 | 2020-10-06 | 5d | 431d | 0d | Litgrid AB | 40h |
| 144 | 5.6.4.5 | Darbo projekto pateikimas Statytojui su žyma "Pritariu statyti" | inactive | 5d | 2022-04-26 | 2022-05-03 | 143 |  |  |  | 426d |  | Rangovas | 40h |

| ID | WBS | Task | Type | Duration | Start | Finish | Predecessors | Baseline start | Baseline finish | Baseline duration | Total slack | Free slack | Resources | Work |
| --- | --- | --- | --- | --- | --- | --- | --- | --- | --- | --- | --- | --- | --- | --- |
| 145 | 5.6.5 | **Procesų valdymas ir automatizacija (RAA)** |  | 45d | 2022-03-04 | 2022-05-10 |  | 2020-08-19 | 2020-10-20 | 45d | 410d |  |  | 360h |
| 146 | 5.6.5.1 | Suprojektuota ir pateikta 1 peržiūrai |  | 20d | 2022-03-04 | 2022-04-04 | 75 | 2020-08-19 | 2020-09-15 | 20d | 410d | 0d | Rangovas | 160h |
| 147 | 5.6.5.2 | Pateiktos pastabos po 1 peržiūros |  | 15d | 2022-04-04 | 2022-04-26 | 146 | 2020-09-16 | 2020-10-06 | 15d | 410d | 0d | Litgrid AB | 120h |
| 148 | 5.6.5.3 | Pakoreguota pagal pastabas ir pateikta 2 peržiūrai |  | 5d | 2022-04-26 | 2022-05-03 | 147 | 2020-10-07 | 2020-10-13 | 5d | 410d | 0d | Rangovas | 40h |
| 149 | 5.6.5.4 | Darbo projekto dalis suderinta |  | 5d | 2022-05-03 | 2022-05-10 | 148 | 2020-10-14 | 2020-10-20 | 5d | 410d | 0d | Litgrid AB | 40h |
| 150 | 5.6.5.5 | Darbo projekto pateikimas Statytojui su žyma "Pritariu statyti" | inactive | 5d | 2022-05-10 | 2022-05-17 | 149 |  |  |  | 416d |  | Rangovas | 40h |
| 151 | 5.6.6 | **Procesų valdymas ir automatizacija (TSPĮ)** |  | 35d | 2020-12-14 | 2021-02-03 |  | 2020-08-19 | 2020-10-06 | 35d | 740d |  |  | 280h |
| 152 | 5.6.6.1 | Suprojektuota ir pateikta 1 peržiūrai |  | 10d | 2020-12-14 | 2020-12-29 | 80 | 2020-08-19 | 2020-09-01 | 10d | 732d | 0d | Rangovas | 80h |
| 153 | 5.6.6.2 | Pateiktos pastabos po 1 peržiūros |  | 15d | 2020-12-29 | 2021-01-20 | 152 | 2020-09-02 | 2020-09-22 | 15d | 732d | 0d | Litgrid AB | 120h |
| 154 | 5.6.6.3 | Pakoreguota pagal pastabas ir pateikta 2 peržiūrai |  | 5d | 2021-01-20 | 2021-01-27 | 153 | 2020-09-23 | 2020-09-29 | 5d | 732d | 0d | Rangovas | 40h |
| 155 | 5.6.6.4 | Darbo projekto dalis suderinta |  | 5d | 2021-01-27 | 2021-02-03 | 154 | 2020-09-30 | 2020-10-06 | 5d | 732d | 0d | Litgrid AB | 40h |
| 156 | 5.6.6.5 | Darbo projekto pateikimas Statytojui su žyma "Pritariu statyti" | inactive | 5d | 2021-02-03 | 2021-02-10 | 155 |  |  |  | 735d |  | Rangovas | 40h |
| 157 | 5.6.7 | **Procesų valdymas ir automatizacija (EEA)** |  | 35d | 2022-03-04 | 2022-04-26 |  | 2020-08-19 | 2020-10-06 | 35d | 431d |  |  | 280h |
| 158 | 5.6.7.1 | Suprojektuota ir pateikta 1 peržiūrai |  | 10d | 2022-03-04 | 2022-03-21 | 85 | 2020-08-19 | 2020-09-01 | 10d | 431d | 0d | Rangovas | 80h |
| 159 | 5.6.7.2 | Pateiktos pastabos po 1 peržiūros |  | 15d | 2022-03-21 | 2022-04-11 | 158 | 2020-09-02 | 2020-09-22 | 15d | 431d | 0d | Litgrid AB | 120h |
| 160 | 5.6.7.3 | Pakoreguota pagal pastabas ir pateikta 2 peržiūrai |  | 5d | 2022-04-11 | 2022-04-19 | 159 | 2020-09-23 | 2020-09-29 | 5d | 431d | 0d | Rangovas | 40h |
| 161 | 5.6.7.4 | Darbo projekto dalis suderinta |  | 5d | 2022-04-19 | 2022-04-26 | 160 | 2020-09-30 | 2020-10-06 | 5d | 431d | 0d | Litgrid AB | 40h |
| 162 | 5.6.7.5 | Darbo projekto pateikimas Statytojui su žyma "Pritariu statyti" | inactive | 5d | 2022-04-26 | 2022-05-03 | 161 |  |  |  | 426d |  | Rangovas | 40h |
| 163 | 5.6.8 | **Telekomunikacijos (TK)** |  | 40d | 2022-03-04 | 2022-05-03 |  | 2020-08-19 | 2020-10-13 | 40d | 426d |  |  | 320h |
| 164 | 5.6.8.1 | Suprojektuota ir pateikta 1 peržiūrai |  | 15d | 2022-03-04 | 2022-03-28 | 90 | 2020-08-19 | 2020-09-08 | 15d | 426d | 0d | Rangovas | 120h |
| 165 | 5.6.8.2 | Pateiktos pastabos po 1 peržiūros |  | 15d | 2022-03-28 | 2022-04-19 | 164 | 2020-09-09 | 2020-09-29 | 15d | 426d | 0d | Litgrid AB | 120h |
| 166 | 5.6.8.3 | Pakoreguota pagal pastabas ir pateikta 2 peržiūrai |  | 5d | 2022-04-19 | 2022-04-26 | 165 | 2020-09-30 | 2020-10-06 | 5d | 426d | 0d | Rangovas | 40h |
| 167 | 5.6.8.4 | Darbo projekto dalis suderinta |  | 5d | 2022-04-26 | 2022-05-03 | 166 | 2020-10-07 | 2020-10-13 | 5d | 426d | 0d | Litgrid AB | 40h |
| 168 | 5.6.8.5 | Darbo projekto pateikimas Statytojui su žyma "Pritariu statyti" | inactive | 5d | 2022-05-03 | 2022-05-10 | 167 |  |  |  | 421d |  | Rangovas | 40h |

| ID | WBS | Task | Type | Duration | Start | Finish | Predecessors | Baseline start | Baseline finish | Baseline duration | Total slack | Free slack | Resources | Work | Cost |
| --- | --- | --- | --- | --- | --- | --- | --- | --- | --- | --- | --- | --- | --- | --- | --- |
| 169 | 5.6.9 | **Apsauginės-gaisrinės signalizacija (AGS)** |  | 35d | 2022-03-04 | 2022-04-26 |  | 2020-08-19 | 2020-10-06 | 35d | 431d |  |  | 280h |  |
| 170 | 5.6.9.1 | Suprojektuota ir pateikta 1 peržiūrai |  | 10d | 2022-03-04 | 2022-03-21 | 95 | 2020-08-19 | 2020-09-01 | 10d | 431d | 0d | Rangovas | 80h |  |
| 171 | 5.6.9.2 | Pateiktos pastabos po 1 peržiūros |  | 15d | 2022-03-21 | 2022-04-11 | 170 | 2020-09-02 | 2020-09-22 | 15d | 431d | 0d | Litgrid AB | 120h |  |
| 172 | 5.6.9.3 | Pakoreguota pagal pastabas ir pateikta 2 peržiūrai |  | 5d | 2022-04-11 | 2022-04-19 | 171 | 2020-09-23 | 2020-09-29 | 5d | 431d | 0d | Rangovas | 40h |  |
| 173 | 5.6.9.4 | Darbo projekto dalis suderinta |  | 5d | 2022-04-19 | 2022-04-26 | 172 | 2020-09-30 | 2020-10-06 | 5d | 431d | 0d | Litgrid AB | 40h |  |
| 174 | 5.6.9.5 | Darbo projekto pateikimas Statytojui su žyma "Pritariu statyti" | inactive | 5d | 2022-04-26 | 2022-05-03 | 173 |  |  |  | 426d |  | Rangovas | 40h |  |
| 175 | 5.6.10 | **Vandentiekio ir nuotekų dalis (VN)** |  | 35d | 2022-05-17 | 2022-07-07 |  | 2020-11-26 | 2021-01-18 | 35d | 381d |  |  | 280h |  |
| 176 | 5.6.10.1 | Suprojektuota ir pateikta 1 peržiūrai |  | 10d | 2022-05-17 | 2022-05-31 | 118 | 2020-11-26 | 2020-12-09 | 10d | 381d | 0d | Rangovas | 80h |  |
| 177 | 5.6.10.2 | Pateiktos pastabos po 1 peržiūros |  | 15d | 2022-05-31 | 2022-06-21 | 176 | 2020-12-10 | 2021-01-04 | 15d | 381d | 0d | Litgrid AB | 120h |  |
| 178 | 5.6.10.3 | Pakoreguota pagal pastabas ir pateikta 2 peržiūrai |  | 5d | 2022-06-21 | 2022-06-29 | 177 | 2021-01-05 | 2021-01-11 | 5d | 381d | 0d | Rangovas | 40h |  |
| 179 | 5.6.10.4 | Darbo projekto dalis suderinta |  | 5d | 2022-06-29 | 2022-07-07 | 178 | 2021-01-12 | 2021-01-18 | 5d | 381d | 0d | Litgrid AB | 40h |  |
| 180 | 5.6.10.5 | Darbo projekto pateikimas Statytojui su žyma "Pritariu statyti" | inactive | 5d | 2022-07-07 | 2022-07-14 | 179 |  |  |  | 376d |  | Rangovas | 40h |  |
| 181 | 5.6.11 | Rangovas pateikia prašymą dėl IP dresų suteikimo |  | 1d | 2022-05-10 | 2022-05-11 | 149 |  |  |  | 410d | 0d |  |  |  |
| 182 | 5.6.12 | IP adresų suteikimas TSPĮ;MDV;GPS;RAA įrenginiams |  | 10d | 2022-05-11 | 2022-05-25 | 181 |  |  |  | 410d |  | Litgrid AB | 80h |  |
| 183 | 5.7 | **Darbų-atjungimų grafikas** |  | 54d | 2022-02-10 | 2022-05-02 |  |  |  |  | 427d |  |  | 752h |  |
| 184 | 5.7.1 | Pateiktas darbų-atjungimų grafikas 1 periūrai | milestone | 0d | 2022-02-10 | 2022-02-10 | 192SS-90d |  |  |  | 427d | 0d | Rangovas |  |  |
| 185 | 5.7.2 | Pateiktos pastabos po 1 peržiūros |  | 15d | 2022-02-10 | 2022-03-04 | 184 |  |  |  | 427d | 0d | Litgrid AB; ESO | 240h |  |
| 186 | 5.7.3 | Pateiktas darbų-atjungimų grafikas 2 peržiūrai |  | 7d | 2022-03-04 | 2022-03-16 | 185 |  |  |  | 427d | 0d | Rangovas | 56h |  |
| 187 | 5.7.4 | Pateiktos pastabos po 2 peržiūros |  | 15d | 2022-03-16 | 2022-04-06 | 186 |  |  |  | 427d | 0d | Litgrid AB; ESO | 240h |  |
| 188 | 5.7.5 | Pateiktas darbų-atjungimų grafikas 3 peržiūrai |  | 7d | 2022-04-06 | 2022-04-15 | 187 |  |  |  | 427d | 0d | Rangovas | 56h |  |
| 189 | 5.7.6 | Suderintas darbų-atjungimų grafikas |  | 10d | 2022-04-15 | 2022-05-02 | 188, 192SS-60d |  |  |  | 427d |  | Litgrid AB; ESO | 160h |  |
| 190 | 5.8 | Statybos aikštelės perdavimas rangovui |  | 3d | 2022-06-21 | 2022-06-27 | 137, 121 |  |  |  | 388d |  | Litgrid AB | 24h |  |
| 191 | 5.9 | **I etapo statybos darbai** |  | 178d | 2022-06-21 | 2023-03-06 |  |  |  |  | 0d |  | Rangovas | 2816h | 427.2 |
| 192 | 5.9.1 | Rangovas detalizuoja darbus |  | 90d | 2022-06-21 | 2022-10-28 | 137, 121 |  |  |  | 0d |  |  |  |  |
| 193 | 5.9.2 | Principinės objekto schemos pateikimas (OL permaitinimai ir kt. Pagal suderintą atjungimų grafiką) |  | 3d | 2022-06-21 | 2022-06-27 | 192SS |  |  |  | 385d | 0d | Rangovas | 24h |  |
| 194 | 5.9.3 | TSM modelio keitimas (dėl I etapo išmontuojamos dalies) |  | 3d | 2022-06-27 | 2022-06-30 | 193 |  |  |  | 385d |  | _ITTAD ITTC VSG DVS administratorius | 24h | 427.2 |
| 195 | 5.9.4 | RAA derinimo darbai |  | 15d | 2022-10-28 | 2022-11-21 | 192, 115 |  |  |  | 0d |  | Rangovas | 120h |  |
| 196 | 5.9.5 | TSPĮ įrangos derinimo darbai |  | 15d | 2022-11-21 | 2022-12-12 | 195 |  |  |  | 0d |  | Rangovas | 120h |  |
| 197 | 5.9.6 | Teleinformacijos testavimai tarp RAA terminalų (valdiklių) ir TSPĮ |  | 1d | 2022-12-12 | 2022-12-13 | 196 |  |  |  | 264d | 0d | Rangovas; Litgrid AB | 16h |  |
| 198 | 5.9.7 | Ryšių; įrangos derinimo darbai |  | 15d | 2022-11-21 | 2022-12-12 | 196SS |  |  |  | 0d |  | Rangovas | 120h |  |
| 199 | 5.9.8 | Užsakymo pateikimas duomenų telekomunikacijų įrangos prijungimui į Litgrid AB TDPT |  | 1d | 2022-12-12 | 2022-12-13 | 198 |  |  |  | 0d |  | Rangovas | 8h |  |
| 200 | 5.9.9 | Litgrid AB TDPT įrangos parengimas/konfigūravimas naujos telekomunikacijų įrangos (IP; SDH; RRL; Šviesolaidis) prijungimui |  | 4d | 2022-12-13 | 2022-12-19 | 199 |  |  |  | 0d |  | Litgrid AB | 32h |  |
| 201 | 5.9.10 | RAA OĮB rengimas/tvirtinimas |  | 10d | 2022-12-12 | 2022-12-27 | 196, 198 |  |  |  | 251d | 0d | Rangovas; Litgrid AB | 160h |  |
| 202 | 5.9.11 | Tipinių perjungimo lapelių ruošimas/tvirtinimas |  | 10d | 2022-12-27 | 2023-01-10 | 201 |  |  |  | 251d |  | Rangovas | 80h |  |

Notes:
- 181: Reikia RAA nuostatų ir signalų sąrašo suderinto

| ID | WBS | Task | Type | Duration | Start | Finish | Predecessors | Total slack | Free slack | Resources | Work |
| --- | --- | --- | --- | --- | --- | --- | --- | --- | --- | --- | --- |
| 203 | 5.9.12 | **DVS (SCADA/EMS) parengiamieji darbai kompleksiniams bandymams (DVS realaus laiko displėjų parengimas; DVS vystymo sistemos konfigūravimas)** |  | 11d | 2022-08-24 | 2022-09-08 |  | 81d |  |  | 88h |
| 204 | 5.9.12.1 | DVS vystymo sistemos konfigūravimas pagal paskutinį suderintą signalų sąrašą |  | 3d | 2022-08-24 | 2022-08-29 | 115 | 81d | 0d | Litgrid AB | 24h |
| 205 | 5.9.12.2 | Principinės objekto schemos pateikimas; linijų; transformatorių parametrų pateikimas |  | 3d | 2022-08-29 | 2022-09-01 | 204 | 81d | 0d | Rangovas | 24h |
| 206 | 5.9.12.3 | DVS realaus laiko displėjų parengimas |  | 5d | 2022-09-01 | 2022-09-08 | 204, 205 | 81d |  | Litgrid AB | 40h |
| 207 | 5.9.13 | TSPĮ konfigūracijos pateikimas |  | 1d | 2022-12-13 | 2022-12-14 | 197 | 264d | 0d | Rangovas | 8h |
| 208 | 5.9.14 | TSPĮ konfigūracijos derinimas su užsakovu |  | 5d | 2022-12-14 | 2022-12-21 | 207 | 264d |  | Litgrid AB | 40h |
| 209 | 5.9.15 | Įrenginių testavimas bandymai objekte ir/ar tarp skirtingų objektų (pasiruošimas kompleksiniams bandymas) |  | 10d | 2022-12-19 | 2023-01-03 | 200 | 0d |  | Rangovas | 80h |
| 210 | 5.9.16 | Įrenginių kompleksiniai bandymai su PSO SCADA |  | 7d | 2023-01-03 | 2023-01-12 | 206, 209 | 0d |  | Rangovas; Litgrid AB | 112h |
| 211 | 5.9.17 | **DVS (SCADA/EMS) baigiamieji etapo darbai** |  | 11d | 2023-01-12 | 2023-01-27 |  | 0d |  |  | 120h |
| 212 | 5.9.17.1 | Konfigūracijos perkėlimas iš vystymo DVS į darbinę DVS |  | 1d | 2023-01-12 | 2023-01-13 | 210 | 0d |  | Litgrid AB | 8h |
| 213 | 5.9.17.2 | Skaičiuojamųjų matavimų sukonfigūravimas DVS |  | 3d | 2023-01-13 | 2023-01-18 | 212 | 0d |  | Litgrid AB | 24h |
| 214 | 5.9.17.3 | DVS realaus laiko displėjų parengimo užbaigimas |  | 7d | 2023-01-18 | 2023-01-27 | 213 | 238d |  | Litgrid AB | 56h |
| 215 | 5.9.17.4 | DVS teisių koregavimas (jeigu įtraukiamas naujas objektas) |  | 1d | 2023-01-18 | 2023-01-19 | 213 | 0d |  | Litgrid AB | 8h |
| 216 | 5.9.17.5 | TSM modelio keitimas (dėl I etapo) |  | 2d | 2023-01-19 | 2023-01-23 | 215, 205 | 0d |  | Litgrid AB | 16h |
| 217 | 5.9.17.6 | TDPT naujos įrangos įvedimas į monitoringo ir valdymo sistemas |  | 1d | 2023-01-23 | 2023-01-24 | 216 | 0d |  | Litgrid AB | 8h |
| 218 | 5.9.18 | **Techninio įvertinimo komisija (I etapo)** |  | 28d | 2023-01-24 | 2023-03-06 |  | 0d |  |  | 240h |
| 219 | 5.9.18.1 | Techninės dokumentacijos pateikimas Užsakovui |  | 5d | 2023-01-24 | 2023-01-31 | 217 | 0d |  | Rangovas | 40h |
| 220 | 5.9.18.2 | Tech priežiūra derina/pateikia pastabas dokumentacijai |  | 7d | 2023-01-31 | 2023-02-09 | 219 | 0d |  | Litgrid AB | 56h |
| 221 | 5.9.18.3 | Operatyvinio personalo mokymai |  | 1d | 2023-02-09 | 2023-02-10 | 220 | 0d |  | Rangovas | 8h |
| 222 | 5.9.18.4 | Rangovas pateikia raštą dėl TĮK organizavimo (su tech. priežiūros vadovo parašu) |  | 1d | 2023-02-10 | 2023-02-13 | 221 | 0d |  | Rangovas | 8h |
| 223 | 5.9.18.5 | TĮK organizavimas |  | 7d | 2023-02-13 | 2023-02-23 | 222 | 0d |  | Litgrid AB | 56h |
| 224 | 5.9.18.6 | Techninio įvertinimo komisija | milestone | 0d | 2023-02-23 | 2023-02-23 | 223 | 0d |  | Rangovas; Litgrid AB |  |
| 225 | 5.9.18.7 | TĮK pastabų šalinimas |  | 5d | 2023-02-23 | 2023-03-02 | 224 | 0d |  | Rangovas | 40h |
| 226 | 5.9.18.8 | TP įjungimas; bandomoji ekspoatacija |  | 2d | 2023-03-02 | 2023-03-06 | 225 | 0d |  | Rangovas; Litgrid AB | 32h |
| 227 | 5.9.18.9 | TP įjungta | milestone | 0d | 2023-03-06 | 2023-03-06 | 226 | 0d |  | Rangovas; Litgrid AB |  |

| ID | WBS | Task | Duration | Start | Finish | Predecessors | Total slack | Free slack | Resources | Work | Cost |
| --- | --- | --- | --- | --- | --- | --- | --- | --- | --- | --- | --- |
| 228 | 5.10 | **II etapo statybos darbai** | 162d | 2023-03-06 | 2023-10-24 |  | 0d |  | Rangovas | 4264h | 4,984 |
| 229 | 5.10.1 | Rangovas detalizuoja darbus | 70d | 2023-03-06 | 2023-06-14 | 227 | 0d |  |  |  |  |
| 230 | 5.10.2 | **RAA nuostatų pateikimas II statybos etapui** | 35d | 2023-03-06 | 2023-04-25 |  | 29d |  |  | 280h |  |
| 231 | 5.10.2.1 | OL RAA nuostatų II rekonstrukcijos etapui skaičiavimas | 21d | 2023-03-06 | 2023-04-04 | 229SS | 29d | 0d | Litgrid AB | 168h |  |
| 232 | 5.10.2.2 | OL RAA nuostatų II rekonstrukcijos etapo užduočių rengimas | 13d | 2023-04-04 | 2023-04-24 | 231 | 29d | 0d | Litgrid AB | 104h |  |
| 233 | 5.10.2.3 | Užduočių pateikimas | 1d | 2023-04-24 | 2023-04-25 | 232 | 29d | 0d | Litgrid AB | 8h |  |
| 234 | 5.10.3 | **Gretimų TP RAA nuostatų pateikimas** | 31d | 2023-04-25 | 2023-06-08 |  | 76d |  |  | 248h |  |
| 235 | 5.10.3.1 | OL RAA nuostatų gretimose TP skaičiavimas | 20d | 2023-04-25 | 2023-05-24 | 233 | 76d | 0d | Litgrid AB | 160h |  |
| 236 | 5.10.3.2 | OL RAA nuostatų gretimose TP užduočių rengimas | 10d | 2023-05-24 | 2023-06-07 | 235 | 76d | 0d | Litgrid AB | 80h |  |
| 237 | 5.10.3.3 | Užduočių pateikimas | 1d | 2023-06-07 | 2023-06-08 | 236 | 76d |  | Litgrid AB | 8h |  |
| 238 | 5.10.4 | **II darbų etapo signalų sąrašai** | 40d | 2023-04-25 | 2023-06-21 |  | 29d |  |  | 320h |  |
| 239 | 5.10.4.1 | Suprojektuoti ir pateikti 1 peržiūrai ir derinimui XX TP; bei kitų su XX TP rekonstrukcija susijusių objektų (pagal poreikį); signalų sąrašai Litgrid AB ir ESO | 10d | 2023-04-25 | 2023-05-10 | 233 | 29d | 0d | Rangovas | 80h |  |
| 240 | 5.10.4.2 | Pateiktos pastabos po 1 peržiūros | 10d | 2023-05-10 | 2023-05-24 | 239 | 29d | 0d | Litgrid AB | 80h |  |
| 241 | 5.10.4.3 | Pakoreguoti pagal pastabas ir pateikti 2 peržiūrai ir derinimui signalų sąrašai Litgrid AB ir ESO | 5d | 2023-05-24 | 2023-05-31 | 240 | 29d | 0d | Rangovas | 40h |  |
| 242 | 5.10.4.4 | Pateiktos pastabos po 2 peržiūros | 5d | 2023-05-31 | 2023-06-07 | 241 | 29d | 0d | Litgrid AB | 40h |  |
| 243 | 5.10.4.5 | Pakoreguoti pagal pastabas ir pateikti III peržiūrai ir derinimui signalų sąrašai Litgrid AB ir ESO | 5d | 2023-06-07 | 2023-06-14 | 242 | 29d | 0d | Rangovas | 40h |  |
| 244 | 5.10.4.6 | II darbų etapo signalų sąrašai suderinti | 5d | 2023-06-14 | 2023-06-21 | 243 | 29d | 0d | Litgrid AB | 40h |  |
| 245 | 5.10.5 | Principinės objekto schemos pateikimas (OL permaitinimai ir kt. Pagal suderintą atjungimų grafiką) | 3d | 2023-03-06 | 2023-03-09 | 229SS | 207d | 0d | Rangovas | 24h |  |
| 246 | 5.10.6 | TSM modelio keitimas (dėl II etapo išmontuojamos dalies) | 3d | 2023-03-09 | 2023-03-14 | 245 | 207d |  | _ITTAD ITTC VSG DVS administratorius | 24h | 427.2 |
| 247 | 5.10.7 | RAA derinimo darbai | 15d | 2023-06-14 | 2023-07-05 | 229 | 0d |  | Rangovas | 120h |  |
| 248 | 5.10.8 | TSPĮ įrangos derinimo darbai | 15d | 2023-07-05 | 2023-07-27 | 247 | 0d |  | Rangovas | 120h |  |
| 249 | 5.10.9 | Pastotės RAA terminalų; teleinformacijos surinkimo ir perdavimo įrenginių (TSPĮ); ryšių įrangos; informacijos saugumo reikalavimų išpildymo tikrinimas su LITGRID AB. | 1d | 2023-07-26 | 2023-07-27 | 248FF | 113d |  | Rangovas | 8h |  |
| 250 | 5.10.10 | Teleinformacijos testavimai tarp RAA terminalų (valdiklių) ir TSPĮ | 1d | 2023-07-27 | 2023-07-28 | 248 | 106d | 0d | Rangovas; Litgrid AB | 16h |  |
| 251 | 5.10.11 | Ryšių; įrangos derinimo darbai | 15d | 2023-07-05 | 2023-07-27 | 248SS | 0d |  | Rangovas | 120h |  |
| 252 | 5.10.12 | Užsakymo pateikimas duomenų telekomunikacijų įrangos prijungimui į Litgrid AB TDPT | 1d | 2023-07-27 | 2023-07-28 | 251 | 0d |  | Litgrid AB | 8h |  |
| 253 | 5.10.13 | Litgrid AB TDPT įrangos parengimas/konfigūravimas naujos telekomunikacijų įrangos (IP; SDH; RRL; Šviesolaidis) prijungimui (Litgrid AB) | 4d | 2023-07-28 | 2023-08-03 | 252 | 0d |  | _ITTAD ITTC DPG duomenų tinklo administratorius (KR); _ITTAD ITTC TIG vyresnysis inžinierius; Litgrid AB; _ITTAD ITTC DPG duomenų tinklo administratorius (IP) | 128h | 1,708.8 |
| 254 | 5.10.14 | RAA OĮB rengimas/tvirtinimas | 10d | 2023-07-27 | 2023-08-10 | 248, 251 | 93d | 0d | Rangovas; Litgrid AB | 160h |  |
| 255 | 5.10.15 | Tipinių perjungimo lapelių ruošimas/tvirtinimas | 10d | 2023-08-10 | 2023-08-25 | 254 | 93d |  | Rangovas | 80h |  |

| ID | WBS | Task | Type | Duration | Start | Finish | Predecessors | Total slack | Free slack | Resources | Work | Cost |
| --- | --- | --- | --- | --- | --- | --- | --- | --- | --- | --- | --- | --- |
| 256 | 5.10.16 | **DVS (SCADA/EMS) parengiamieji darbai kompleksiniams bandymams (DVS realaus laiko displėjų parengimas; DVS pagrindinio/rezervinio centro konfigūravimas)** |  | 11d | 2023-06-21 | 2023-07-07 |  | 29d |  |  | 88h |  |
| 257 | 5.10.16.1 | DVS pagrindinio/rezervinio centro konfigūravimas atsižvelgiant į etapo pasikeitmus 3-5 d.d. |  | 3d | 2023-06-21 | 2023-06-26 | 244 | 29d | 0d | Litgrid AB | 24h |  |
| 258 | 5.10.16.2 | Principinės objekto schemos pateikimas; linijų; transformatorių parametrų pateikimas |  | 3d | 2023-06-26 | 2023-06-29 | 257 | 29d | 0d | Rangovas | 24h |  |
| 259 | 5.10.16.3 | DVS realaus laiko displėjų parengimas 3-5 d.d. (SVD darbai) |  | 5d | 2023-06-29 | 2023-07-07 | 257, 258 | 29d |  | Litgrid AB | 40h |  |
| 260 | 5.10.17 | TSPĮ konfigūracijos pateikimas |  | 1d | 2023-07-28 | 2023-07-31 | 250 | 106d | 0d | Rangovas | 8h |  |
| 261 | 5.10.18 | TSPĮ konfigūracijos derinimas su užsakovu (Litgrid AB) |  | 5d | 2023-07-31 | 2023-08-07 | 260 | 106d |  | Litgrid AB | 40h |  |
| 262 | 5.10.19 | II etapo įrenginių testavimas bandymai objekte ir/ar tarp skirtingų objektų (pasiruošimas kompleksiniams bandymas) |  | 10d | 2023-08-03 | 2023-08-18 | 253 | 0d |  | Rangovas | 80h |  |
| 263 | 5.10.20 | II etapo įrenginių kompleksiniai bandymai su PSO SCADA |  | 7d | 2023-08-21 | 2023-08-29 | 259, 262 | 0d |  | Rangovas; Litgrid AB | 112h |  |
| 264 | 5.10.21 | **DVS (SCADA/EMS) baigiamojo etapo darbai)** |  | 56d | 2023-06-29 | 2023-09-19 |  | 76d |  |  | 488h | 2,848 |
| 265 | 5.10.21.1 | Skaičiuojamųjų matavimų koregavimas DVS |  | 3d | 2023-08-29 | 2023-09-01 | 263 | 76d | 0d | Litgrid AB | 24h |  |
| 266 | 5.10.21.2 | DVS realaus laiko displėjų parengimo užbaigimas |  | 7d | 2023-09-04 | 2023-09-12 | 265 | 76d | 0d | Litgrid AB | 56h |  |
| 267 | 5.10.21.3 | Pateikiama rekonstrukcijos II etapo schema ir parametrai |  | 5d | 2023-09-12 | 2023-09-19 | 266 | 76d |  | Rangovas | 40h |  |
| 268 | 5.10.21.4 | TSM modelio keitimas (dėl II etapo) |  | 2d | 2023-06-29 | 2023-07-03 | 258 | 96d | 0d | Litgrid AB | 16h |  |
| 269 | 5.10.21.5 | Visos būtinos dokumentacijos įrenginių įjungimui patvirtinimas/vizavimas; Pateiktas galutinis TPL sąrašas suvedimui į DVS |  | 2d | 2023-07-03 | 2023-07-05 | 268 | 96d | 0d | Rangovas | 16h |  |
| 270 | 5.10.21.6 | Automatinių tipinių perjungimo lapelių suvedimas į PSO DVS |  | 20d | 2023-07-05 | 2023-08-03 | 269 | 96d | 0d | _ITTAD ITTC VSG DVS administratorius | 160h | 2,848 |
| 271 | 5.10.21.7 | Automatinių tipinių perjungimo lapelių testavimas realiomis sąlygomis |  | 10d | 2023-08-03 | 2023-08-18 | 270 | 96d | 0d | Rangovas; Litgrid AB | 160h |  |
| 272 | 5.10.21.8 | TDPT naujos įrangos įvedimas į monitoringo ir valdymo sistemas |  | 2d | 2023-08-21 | 2023-08-22 | 271 | 96d |  | Litgrid AB | 16h |  |
| 273 | 5.10.22 | **Techninio įvertinimo komisija (II etapo)** |  | 20d | 2023-08-29 | 2023-09-26 |  | 0d |  |  | 336h |  |
| 274 | 5.10.22.1 | Techninės dokumentacijos pateikimas Užsakovui pagal techninės užduoties reikalavimus |  | 1d | 2023-08-29 | 2023-08-30 | 263 | 0d |  | Rangovas | 8h |  |
| 275 | 5.10.22.2 | Techninės dokumentacijos pateikimas ir derinimas su Užsakovu pagal techninės užduoties reikalavimus |  | 5d | 2023-08-30 | 2023-09-06 | 274 | 0d |  | Litgrid AB | 192h |  |
| 276 | 5.10.22.3 | Operatyvinio personalo mokymai |  | 1d | 2023-09-06 | 2023-09-07 | 275 | 0d |  | Rangovas | 8h |  |
| 277 | 5.10.22.4 | Įjungimo programos rengimas ir derinimas |  | 5d | 2023-09-07 | 2023-09-14 | 276 | 0d |  | Rangovas | 40h |  |
| 278 | 5.10.22.5 | Techninio įvertinimo komisija (II etapo) |  | 1d | 2023-09-14 | 2023-09-15 | 277 | 0d |  | Rangovas; Litgrid AB | 16h |  |
| 279 | 5.10.22.6 | Techninio įvertinimo komisijos (II etapo) pastabų šalinimas |  | 5d | 2023-09-18 | 2023-09-22 | 278 | 0d |  | Rangovas | 40h |  |
| 280 | 5.10.22.7 | TP įjungimas; bandomoji ekspoatacija |  | 2d | 2023-09-25 | 2023-09-26 | 279 | 0d |  | Rangovas; Litgrid AB | 32h |  |
| 281 | 5.10.22.8 | TP įjungta | milestone | 0d | 2023-09-26 | 2023-09-26 | 280 | 0d |  | Rangovas; Litgrid AB |  |  |
| 282 | 5.10.23 | RAA nuostatų keitimas gretimose TP |  | 20d | 2023-09-26 | 2023-10-24 | 281, 237 | 0d |  | Rangovas | 160h |  |
| 283 | 5.10.24 | RANGOS DARBAI OBJEKTE BAIGTI | milestone | 0d | 2023-10-24 | 2023-10-24 | 282 | 0d |  |  |  |  |

Notes:
- 256: (3-5 d.d. priklauso nuo apimties, kiekvieno projekto metu derinama atskirai)
- 264: (14-30 d.d. priklauso nuo apimties, kiekvieno projekto metu derinama atskirai)
- 270: (10-20 d.d.; 50 operacijų į dieną kartu su testavimu imitatoriumi)

| ID | WBS | Task | Type | Duration | Start | Finish | Predecessors | Baseline start | Baseline finish | Baseline duration | Total slack | Resources | Work |
| --- | --- | --- | --- | --- | --- | --- | --- | --- | --- | --- | --- | --- | --- |
| 284 | 6 | **III ETAPAS. STATYBOS UŽBAIGIMO AKTAS** |  | 51d | 2023-10-24 | 2024-01-10 |  | 2022-01-19 | 2022-02-18 | 22d | 0d |  | 816h |
| 285 | 6.1 | Išpildomosios topografinės nuotraukos parengimas |  | 20d | 2023-10-24 | 2023-11-22 | 283 |  |  |  | 0d | Rangovas | 160h |
| 286 | 6.2 | **Statinių kadastrinės bylos parengimas; suderinimas ir registrų centro išankstinė patikra** |  | 18d | 2023-11-22 | 2023-12-18 |  |  |  |  | 0d | Rangovas | 288h |
| 287 | 6.2.1 | Rangovas rengia statinių kadastrinė bylą |  | 10d | 2023-11-22 | 2023-12-06 | 285 |  |  |  | 0d | Rangovas | 80h |
| 288 | 6.2.2 | Statinių kadastrinės bylos derinimas |  | 5d | 2023-12-06 | 2023-12-13 | 287 |  |  |  | 0d | Litgrid AB | 40h |
| 289 | 6.2.3 | Statinių kadastrinės bylos išankstinis suderinimas su registrų centru |  | 3d | 2023-12-13 | 2023-12-18 | 288 |  |  |  | 0d | Rangovas | 24h |
| 290 | 6.3 | **Žemės sklypo kadastrinės bylos parengimas; suderinimas ir registrų centro išankstinė patikra** |  | 18d | 2023-11-22 | 2023-12-18 |  |  |  |  | 0d |  | 144h |
| 291 | 6.3.1 | Rangovas rengia žemės sklypo kadastrinė bylą |  | 10d | 2023-11-22 | 2023-12-06 | 285 |  |  |  | 0d | Rangovas | 80h |
| 292 | 6.3.2 | Žemės sklypo kadastrinės bylos derinimas |  | 5d | 2023-12-06 | 2023-12-13 | 291 |  |  |  | 0d | Litgrid AB | 40h |
| 293 | 6.3.3 | Žemės sklypo kadastrinės bylos išankstinis suderinimas su registrų centru |  | 3d | 2023-12-13 | 2023-12-18 | 292 |  |  |  | 0d | Rangovas | 24h |
| 294 | 6.4 | **Statybos užbaigimo procedūrų organizavimas** |  | 13d | 2023-12-19 | 2024-01-10 |  | 2022-01-19 | 2022-02-15 | 20d | 0d | Rangovas | 224h |
| 295 | 6.4.1 | SUA prašymo dokumentų įkėlimas į IS Infostatyba |  | 3d | 2023-12-19 | 2023-12-21 | 289, 293 |  |  |  | 0d | Rangovas | 24h |
| 296 | 6.4.2 | Preliminaraus SUA suderinimas su Litgrid AB (atspausdintas iš IS Infostatyba) |  | 3d | 2023-12-21 | 2023-12-28 | 295 |  |  |  | 0d | Litgrid AB | 24h |
| 297 | 6.4.3 | SUA prašymo pateikimas Infostatyboje |  | 2d | 2023-12-28 | 2024-01-03 | 296 |  |  |  | 0d | Rangovas | 16h |
| 298 | 6.4.4 | Dokumentų peržiūra |  | 3d | 2024-01-03 | 2024-01-08 | 297 |  |  |  | 0d | Infostatyba | 24h |
| 299 | 6.4.5 | Galutinė statybos užbaigimo komisija |  | 2d | 2024-01-08 | 2024-01-10 | 298 | 2022-02-17 | 2022-02-18 | 2d | 0d | Infostatyba; Rangovas | 32h |
| 300 | 6.4.6 | S8 - SUA gautas/Rangos sutarties pabaiga | milestone | 0d | 2024-01-10 | 2024-01-10 | 299 |  |  |  | 0d | Rangovas |  |

Notes:
- 284: Jeigu perkame iki rakto - paliekame / jeigu perkame atskirai - pa�alinti
